# Projektplan mFund envVisio-GI

How a schedule from GanttProject changed from version to version. A marks actual dates.

## Version 1 (saved 2024-07-03)

| ID | WBS | Task | Duration | Start | Finish | Predecessors |
| --- | --- | --- | --- | --- | --- | --- |
| 1 | 1 | **Projektkoordination** | 244d | 2020-09-15 | 2021-08-20 |  |
| 2 |  | Regelmäßige Treffen der AG Anwendungsfall organisieren | 26d | 2020-09-15 | 2020-10-20 |  |
| 3 |  | AG Anwendungsfall Treffen Termin | 0d | 2020-10-21 | 2020-10-21 | 2 |
| 4 |  | Gesamtprojekttreffen Terminfindung | 21d | 2020-12-01 | 2020-12-29 |  |
| 5 |  | Lizenzschließung mit DLZ zur Datennutzung | 16d | 2021-01-04 | 2021-01-25 |  |
| 6 |  | Konsortialmeeting mit Projektträger | 10d | 2021-08-09 | 2021-08-20 |  |
| 7 | 1.6 | **Unterarbeitspaketkoordination** | 168d | 2020-12-02 | 2021-07-23 |  |
| 8 |  | Gespräche zu AP2 (Datenimport) | 6d | 2020-12-02 | 2020-12-09 |  |
| 9 |  | Gespräche zu AP5 organisieren (Services und APIs) | 6d | 2021-03-08 | 2021-03-15 |  |
| 10 |  | Nicht Haupt-AP Aufgaben koordiniert | 0d | 2021-03-16 | 2021-03-16 | 8, 9 |
| 11 |  | Gespräch zu 7.1 (Konzeption und Spezifikation) | 6d | 2020-12-18 | 2020-12-25 |  |
| 12 |  | Gespräch zu 7.4 (Spezifikation des Datenmanagments) | 7d | 2020-12-25 | 2021-01-04 |  |
| 13 |  | Gespräch zu 7.5 (Implementierung von Anwendungsszenarien) | 5d | 2021-07-19 | 2021-07-23 |  |
| 14 | 2 | **Berichtspflichten** | 432d | 2021-04-05 | 2022-11-29 |  |
| 15 |  | Zwischenbericht I | 19d | 2021-04-05 | 2021-04-29 |  |
| 16 |  | Zwischenbericht I eingereicht | 0d | 2021-04-30 | 2021-04-30 | 15 |
| 17 |  | Zwischenbericht II | 19d | 2022-04-04 | 2022-04-28 |  |
| 18 |  | Zwischenbericht II eingereicht | 0d | 2022-04-29 | 2022-04-29 | 17 |
| 19 |  | Schlussbericht | 17d | 2022-11-07 | 2022-11-29 |  |
| 20 |  | Schlussbericht eingereicht | 0d | 2022-11-30 | 2022-11-30 | 19 |
| 21 | 3 | **AP7 (Anwendungsfall Klima und Mobilität)** | 445d | 2020-09-15 | 2022-05-30 |  |
| 22 |  | Präsentation über GDI Dokumente & Anforderungen | 1d | 2020-09-21 | 2020-09-21 |  |
| 23 |  | Relevante GDI Dokumente den Projektpartnern bekannt | 0d | 2020-09-22 | 2020-09-22 | 22 |
| 24 |  | Erste Eruierungen der Anforderungen Anwendungsfall Klima&Mobilität | 26d | 2020-09-15 | 2020-10-20 |  |
| 25 |  | Bereich im GDI-DE Wiki zur Kommunikation und Organisation erstellt | 0d | 2020-10-20 | 2020-10-20 |  |
| 26 |  | Dokumentation des Anwendungsfalls (Klima&Mobilität + inhaltlich&funktional) | 420d | 2020-10-20 | 2022-05-30 | 25 |
| 27 |  | Schärfung der Anforderungen | 29d | 2020-10-22 | 2020-12-01 | 24FS+1d |
| 28 |  | Ausarbeitung der Anwendungsszenarien | 68d | 2020-12-02 | 2021-03-05 | 27 |
| 29 |  | Erste ausgearbeitete Version von Anwendungsfällen der Projektpartner | 0d | 2021-03-08 | 2021-03-08 | 28 |
| 30 |  | Vorformulierung (SMARTer) Szenarien | 65d | 2021-03-05 | 2021-06-03 |  |
| 31 |  | UAP 7.3 (Datenbereitstellung und Visualisierung) | 65d | 2021-03-05 | 2021-06-03 |  |
| 32 |  | SMARTe Ausarbeitung der Anwendungsfälle | 57d | 2021-06-14 | 2021-08-31 | 30, 31 |
| 33 |  | Konsolidierte Ausarbeitung der Anwendungsfälle | 0d | 2021-09-01 | 2021-09-01 | 32 |
| 34 | 4 | **AP8 (Qualitätssicherung und Verwertung)** | 263d | 2021-03-08 | 2022-03-09 |  |
| 35 |  | Erstellung Qualitätsplan | 43d | 2021-03-08 | 2021-05-05 |  |
| 36 |  | Qualitätskonzept erarbeitet | 0d | 2021-05-06 | 2021-05-06 | 35 |
| 37 |  | Überprüfung der Dokumentation | 175d | 2021-05-03 | 2021-12-31 |  |
| 38 |  | Dokumente zur Nachnutzung stehen bereit | 0d | 2022-01-03 | 2022-01-03 | 37 |
| 39 |  | Überprüfung der Datanbank auf Anforderungen der GDI-DE und Projektpartner | 44d | 2021-08-02 | 2021-09-30 | 44, 47 |
| 40 |  | Überprüfung der importierten Daten | 44d | 2021-08-02 | 2021-09-30 |  |
| 41 |  | Überprüfung der Anwendung | 127d | 2021-09-01 | 2022-02-24 | 48SS |
| 42 |  | Vergleich der finalen Anwendung mit SMART-Zielen | 6d | 2022-03-02 | 2022-03-09 | 49 |
| 43 | 5 | **Technische Vorgänge** | 382d | 2020-09-14 | 2022-03-01 |  |
| 44 |  | AP2 (Datenimport) | 189d | 2020-09-14 | 2021-06-03 |  |
| 45 |  | Dateneinsicht Kreis Lippe | 0d | 2021-08-05 | 2021-08-05 |  |
| 46 |  | Erste Datensichtungen | 0d | 2021-06-03 | 2021-06-03 |  |
| 47 |  | Zentrale Datenbank mit allen benötigten Daten | 0d | 2021-08-02 | 2021-08-02 | 44 |
| 48 |  | UAP 7.5 (Implementierung von Anwendungsszenarien) | 78d | 2021-08-31 | 2021-12-16 | 13 |
| 49 |  | Anwendungen sind Betriebsbereit | 0d | 2022-03-02 | 2022-03-02 | 41, 48 |
| 50 | 6 | **Hackathon** | 200d | 2021-08-23 | 2022-05-27 |  |
| 51 |  | Organisation Hackathon | 198d | 2021-08-23 | 2022-05-25 |  |
| 52 |  | Hackathon Durchführung | 2d | 2022-05-26 | 2022-05-27 | 51 |

## Version 2 (saved 2024-07-03)

Last finish stays 2022-11-30.

Removed: 6 Konsortialmeeting mit Projektträger; 45 Dateneinsicht Kreis Lippe

Changed:

| ID | Task | Start | Finish | Duration |
| --- | --- | --- | --- | --- |
| 1 | **Projektkoordination** |  | 2021-08-20 → 2021-07-23 (-28d) | 244d → 224d |
| 31 | SMARTe Ausarbeitung der Anwendungsfälle | 2021-06-14 → 2021-06-04 (-10d) | 2021-08-31 → 2021-07-07 (-55d) | 57d → 24d |
| 32 | Konsolidierte Ausarbeitung der Anwendungsfälle | 2021-09-01 → 2021-07-08 (-55d) | 2021-09-01 → 2021-07-08 (-55d) |  |
| 36 | Überprüfung der Dokumentation |  | 2021-12-31 → 2021-09-30 (-92d) | 175d → 109d |
| 37 | Dokumente zur Nachnutzung stehen bereit | 2022-01-03 → 2021-10-01 (-94d) | 2022-01-03 → 2021-10-01 (-94d) |  |
| 38 | Überprüfung der Datanbank auf Anforderungen der GDI-DE und Projektpartner | 2021-08-02 → 2021-06-28 (-35d) |  | 44d → 69d |
| 39 | Überprüfung der importierten Daten | 2021-08-02 → 2021-06-07 (-56d) |  | 44d → 84d |
| 40 | Überprüfung der Anwendung | 2021-09-01 → 2021-07-26 (-37d) |  | 127d → 154d |
| 45 | Zentrale Datenbank mit allen benötigten Daten | 2021-08-02 → 2021-06-28 (-35d) | 2021-08-02 → 2021-06-28 (-35d) |  |
| 46 | UAP 7.5 (Implementierung von Anwendungsszenarien) | 2021-08-31 → 2021-07-26 (-36d) |  | 78d → 104d |

## Version 3 (saved 2024-07-03)

Last finish 2022-11-30 → 2022-05-27 (-187d).

Added:

| ID | Task | Duration | Start | Finish | Resources |
| --- | --- | --- | --- | --- | --- |
| 20 | Fall: intelligentes/kommunenübergreifendes Verkehrsmanagment | 15d | 2020-12-15 | 2021-01-04 | Kreis Lippe (LIP) |
| 21 | Fall: Harmonisierung von Gebäudedaten | 12d | 2020-12-02 | 2020-12-17 | Vogelsbergkreis (VK) |
| 22 | Fall: Prozessoptimierung der Erstellung von Lärmkarten | 10d | 2020-12-10 | 2020-12-23 | Stadt Leipzig (L) |
| 23 | Fall: ? | 24d | 2020-12-02 | 2021-01-04 | Stadt Dresden (DD) |

Removed: 5 Lizenzschließung mit DLZ zur Datennutzung; 13 Berichtspflichten; 14 Zwischenbericht I; 15 Zwischenbericht I eingereicht; 16 Zwischenbericht II; 17 Zwischenbericht II eingereicht; 18 Schlussbericht; 19 Schlussbericht eingereicht; 32 Konsolidierte Ausarbeitung der Anwendungsfälle

Changed:

| ID | Task | Start | Finish | Duration | Predecessors | Other |
| --- | --- | --- | --- | --- | --- | --- |
| 1 | **Projektkoordination** |  | 2021-07-23 → 2021-06-08 (-45d) | 224d → 191d |  |  |
| 5 | **Unterarbeitspaketkoordination** |  | 2021-07-23 → 2021-06-08 (-45d) | 168d → 135d |  |  |
| 7 | Gespräche zu AP5 (Services und APIs) | 2021-03-08 → 2021-01-04 (-63d) | 2021-03-15 → 2021-01-08 (-66d) | 6d → 5d |  | was named Gespräche zu AP5 organisieren (Services und APIs) |
| 8 | Nicht Haupt-AP Aufgaben koordiniert | 2021-03-16 → 2021-01-11 (-64d) | 2021-03-16 → 2021-01-11 (-64d) |  |  |  |
| 11 | Gespräch zu 7.5 (Implementierung von Anwendungsszenarien) | 2021-07-19 → 2021-06-01 (-48d) | 2021-07-23 → 2021-06-08 (-45d) | 5d → 6d |  |  |
| 12 | **AP7 (Anwendungsfall Klima und Mobilität)** |  | 2022-05-30 → 2021-03-03 (-453d) | 445d → 122d |  |  |
| 17 | Dokumentation des Anwendungsfalls (Klima&Mobilität + inhaltlich&funktional) |  | 2022-05-30 → 2021-02-26 (-458d) | 420d → 94d |  |  |
| 19 | **Ausarbeitung der Anwendungsszenarien** |  | 2021-03-05 → 2021-01-04 (-60d) | 68d → 24d |  |  |
| 24 | Erste ausgearbeitete Version von Anwendungsfällen der Projektpartner | 2021-03-08 → 2021-01-05 (-62d) | 2021-03-08 → 2021-01-05 (-62d) |  |  |  |
| 25 | UAP 7.3 (Datenbereitstellung und Visualisierung) | 2021-03-05 → 2021-01-05 (-59d) | 2021-06-03 → 2021-03-03 (-92d) | 65d → 42d | none → 24 |  |
| 26 | Formulierung SMARTer Szenarien | 2021-03-05 → 2021-01-05 (-59d) | 2021-06-03 → 2021-02-02 (-121d) | 65d → 21d |  | was named Vorformulierung (SMARTer) Szenarien |
| 27 | Konsolidierte Fassung der Anwendungsfälle | 2021-06-04 → 2021-02-03 (-121d) | 2021-07-07 → 2021-02-03 (-154d) | 24d → 0d | 26, 25 → 26 | was named SMARTe Ausarbeitung der Anwendungsfälle |
| 28 | **AP8 (Qualitätssicherung und Verwertung)** | 2021-03-08 → 2021-02-03 (-33d) |  | 263d → 286d | none → 27 |  |
| 29 | Erstellung Qualitätsplan | 2021-03-08 → 2021-02-03 (-33d) | 2021-05-05 → 2021-03-01 (-65d) | 43d → 19d |  |  |
| 30 | Qualitätskonzept erarbeitet | 2021-05-06 → 2021-03-02 (-65d) | 2021-05-06 → 2021-03-02 (-65d) |  |  |  |
| 31 | Überprüfung der Dokumentation | 2021-05-03 → 2021-03-01 (-63d) | 2021-09-30 → 2021-07-01 (-91d) | 109d → 89d | none → 17 |  |
| 32 | Dokumente zur Nachnutzung stehen bereit | 2021-10-01 → 2021-07-02 (-91d) | 2021-10-01 → 2021-07-02 (-91d) |  |  |  |
| 33 | Überprüfung der Datanbank auf Anforderungen der GDI-DE und Projektpartner | 2021-06-28 → 2021-06-02 (-26d) | 2021-09-30 → 2021-09-01 (-29d) | 69d → 66d |  |  |
| 34 | Überprüfung der importierten Daten | 2021-06-07 → 2021-03-01 (-98d) | 2021-09-30 → 2021-06-08 (-114d) | 84d → 72d | none → 39 |  |
| 35 | Überprüfung der Anwendung | 2021-07-26 → 2021-07-01 (-25d) | 2022-02-24 → 2022-02-01 (-23d) |  |  |  |
| 38 | AP2 (Datenimport) |  | 2021-06-03 → 2021-06-01 (-2d) | 189d → 187d |  |  |
| 39 | Erste Datensichtungen | 2021-06-03 → 2021-03-01 (-94d) | 2021-06-03 → 2021-03-01 (-94d) |  |  |  |
| 40 | Zentrale Datenbank mit allen benötigten Daten | 2021-06-28 → 2021-06-02 (-26d) | 2021-06-28 → 2021-06-02 (-26d) |  |  |  |
| 41 | UAP 7.5 (Implementierung von Anwendungsszenarien) | 2021-07-26 → 2021-06-09 (-47d) | 2021-12-16 → 2021-11-01 (-45d) |  |  |  |
| 43 | **Hackathon** | 2021-08-23 → 2022-03-01 (+190d) |  | 200d → 64d |  |  |
| 44 | Organisation Hackathon | 2021-08-23 → 2022-03-01 (+190d) |  | 198d → 62d |  |  |

## Version 4 (saved 2024-07-03)

Last finish 2022-05-27 → 2022-11-30 (+187d).

Added:

| ID | Task | Duration | Start | Finish | Predecessors |
| --- | --- | --- | --- | --- | --- |
| 5 | Lizenzschließung mit DLZ zur Datennutzung | 16d | 2021-01-04 | 2021-01-25 |  |
| 13 | **Berichtspflichten** | 432d | 2021-04-05 | 2022-11-29 |  |
| 14 | Zwischenbericht I | 19d | 2021-04-05 | 2021-04-29 |  |
| 15 | Zwischenbericht I eingereicht | 0d | 2021-04-30 | 2021-04-30 | 14 |
| 16 | Zwischenbericht II | 19d | 2022-04-04 | 2022-04-28 |  |
| 17 | Zwischenbericht II eingereicht | 0d | 2022-04-29 | 2022-04-29 | 16 |
| 18 | Schlussbericht | 17d | 2022-11-07 | 2022-11-29 |  |
| 19 | Schlussbericht eingereicht | 0d | 2022-11-30 | 2022-11-30 | 18 |
| 32 | Konsolidierte Ausarbeitung der Anwendungsfälle | 0d | 2021-07-08 | 2021-07-08 | 31 |

Removed: 20 Fall: intelligentes/kommunenübergreifendes Verkehrsmanagment; 21 Fall: Harmonisierung von Gebäudedaten; 22 Fall: Prozessoptimierung der Erstellung von Lärmkarten; 23 Fall: ?

Changed:

| ID | Task | Start | Finish | Duration | Predecessors | Other |
| --- | --- | --- | --- | --- | --- | --- |
| 8 | Gespräche zu AP5 organisieren (Services und APIs) | 2021-01-04 → 2021-03-08 (+63d) | 2021-01-08 → 2021-03-15 (+66d) | 5d → 6d |  | was named Gespräche zu AP5 (Services und APIs) |
| 9 | Nicht Haupt-AP Aufgaben koordiniert | 2021-01-11 → 2021-03-16 (+64d) | 2021-01-11 → 2021-03-16 (+64d) |  |  |  |
| 20 | **AP7 (Anwendungsfall Klima und Mobilität)** |  | 2021-03-03 → 2022-05-30 (+453d) | 122d → 445d |  |  |
| 25 | Dokumentation des Anwendungsfalls (Klima&Mobilität + inhaltlich&funktional) |  | 2021-02-26 → 2022-05-30 (+458d) | 94d → 420d |  |  |
| 27 | Ausarbeitung der Anwendungsszenarien |  | 2021-01-04 → 2021-03-05 (+60d) | 24d → 68d |  |  |
| 28 | Erste ausgearbeitete Version von Anwendungsfällen der Projektpartner | 2021-01-05 → 2021-03-08 (+62d) | 2021-01-05 → 2021-03-08 (+62d) |  |  |  |
| 29 | Vorformulierung (SMARTer) Szenarien | 2021-01-05 → 2021-03-05 (+59d) | 2021-02-02 → 2021-06-03 (+121d) | 21d → 65d |  | was named Formulierung SMARTer Szenarien |
| 30 | UAP 7.3 (Datenbereitstellung und Visualisierung) | 2021-01-05 → 2021-03-05 (+59d) | 2021-03-03 → 2021-06-03 (+92d) | 42d → 65d | 28 → none |  |
| 31 | SMARTe Ausarbeitung der Anwendungsfälle | 2021-02-03 → 2021-06-04 (+121d) | 2021-02-03 → 2021-07-07 (+154d) | 0d → 24d | 29 → 29, 30 | was named Konsolidierte Fassung der Anwendungsfälle |
| 33 | **AP8 (Qualitätssicherung und Verwertung)** | 2021-02-03 → 2021-03-08 (+33d) |  | 286d → 263d | 31 → none |  |
| 34 | Erstellung Qualitätsplan | 2021-02-03 → 2021-03-08 (+33d) | 2021-03-01 → 2021-05-05 (+65d) | 19d → 43d |  |  |
| 35 | Qualitätskonzept erarbeitet | 2021-03-02 → 2021-05-06 (+65d) | 2021-03-02 → 2021-05-06 (+65d) |  |  |  |
| 36 | Überprüfung der Dokumentation | 2021-03-01 → 2021-05-03 (+63d) | 2021-07-01 → 2021-07-05 (+4d) | 89d → 46d | 25 → none |  |
| 37 | Dokumente zur Nachnutzung stehen bereit | 2021-07-02 → 2021-07-06 (+4d) | 2021-07-02 → 2021-07-06 (+4d) |  |  |  |
| 38 | Überprüfung der Datanbank auf Anforderungen der GDI-DE und Projektpartner | 2021-06-02 → 2021-06-04 (+2d) | 2021-09-01 → 2021-09-03 (+2d) |  |  |  |
| 39 | Überprüfung der importierten Daten | 2021-03-01 → 2021-06-07 (+98d) | 2021-06-08 → 2021-09-01 (+85d) | 72d → 63d | 44 → none |  |
| 43 | AP2 (Datenimport) |  | 2021-06-01 → 2021-06-03 (+2d) | 187d → 189d |  |  |
| 44 | Erste Datensichtungen | 2021-03-01 → 2021-06-03 (+94d) | 2021-03-01 → 2021-06-03 (+94d) |  |  |  |
| 45 | Zentrale Datenbank mit allen benötigten Daten | 2021-06-02 → 2021-06-04 (+2d) | 2021-06-02 → 2021-06-04 (+2d) |  |  |  |

## Version 5 (saved 2024-07-03)

Last finish 2022-11-30 → 2022-05-27 (-187d).

Added:

| ID | Task | Duration | Start | Finish | Resources |
| --- | --- | --- | --- | --- | --- |
| 21 | Fall: intelligentes/kommunenübergreifendes Verkehrsmanagment | 21d | 2020-12-15 | 2021-01-12 | Kreis Lippe (LIP) |
| 22 | Fall: Harmonisierung von Gebäudedaten | 12d | 2020-12-02 | 2020-12-17 | Vogelsbergkreis (VK) |
| 23 | Fall: Prozessoptimierung der Erstellung von Lärmkarten | 10d | 2020-12-10 | 2020-12-23 | Stadt Leipzig (L) |
| 24 | Fall: ? | 30d | 2020-12-02 | 2021-01-12 | Stadt Dresden (DD) |

Removed: 13 Berichtspflichten; 14 Zwischenbericht I; 15 Zwischenbericht I eingereicht; 16 Zwischenbericht II; 17 Zwischenbericht II eingereicht; 18 Schlussbericht; 19 Schlussbericht eingereicht; 32 Konsolidierte Ausarbeitung der Anwendungsfälle

Changed:

| ID | Task | Start | Finish | Duration | Predecessors | Other |
| --- | --- | --- | --- | --- | --- | --- |
| 5 | Lizenzschließung mit DLZ zur Datennutzung |  | 2021-01-25 → 2021-01-18 (-7d) | 16d → 11d |  |  |
| 8 | Gespräche zu AP5 (Services und APIs) | 2021-03-08 → 2021-01-11 (-56d) | 2021-03-15 → 2021-01-18 (-56d) |  |  | was named Gespräche zu AP5 organisieren (Services und APIs) |
| 9 | Nicht Haupt-AP Aufgaben koordiniert | 2021-03-16 → 2021-01-25 (-50d) | 2021-03-16 → 2021-01-25 (-50d) |  |  |  |
| 13 | **AP7 (Anwendungsfall Klima und Mobilität)** |  | 2022-05-30 → 2021-03-31 (-425d) | 445d → 142d |  |  |
| 18 | Dokumentation des Anwendungsfalls (Klima&Mobilität + inhaltlich&funktional) |  | 2022-05-30 → 2021-02-26 (-458d) | 420d → 94d |  |  |
| 20 | **Ausarbeitung der Anwendungsszenarien** |  | 2021-03-05 → 2021-01-12 (-52d) | 68d → 30d |  |  |
| 25 | Erste ausgearbeitete Version von Anwendungsfällen der Projektpartner | 2021-03-08 → 2021-01-13 (-54d) | 2021-03-08 → 2021-01-13 (-54d) |  |  |  |
| 26 | Formulierung (SMARTer) Szenarien | 2021-03-05 → 2021-01-12 (-52d) | 2021-06-03 → 2021-02-09 (-114d) | 65d → 21d |  | was named Vorformulierung (SMARTer) Szenarien |
| 27 | Konsolidierte Fassung der Anwendungsfälle | 2021-06-04 → 2021-02-10 (-114d) | 2021-07-07 → 2021-02-10 (-147d) | 24d → 0d | 26, 28 → 26 | was named SMARTe Ausarbeitung der Anwendungsfälle |
| 28 | UAP 7.3 (Datenbereitstellung und Visualisierung) | 2021-03-05 → 2021-02-10 (-23d) | 2021-06-03 → 2021-03-31 (-64d) | 65d → 36d | none → 27 |  |
| 29 | **AP8 (Qualitätssicherung und Verwertung)** | 2021-03-08 → 2021-02-10 (-26d) |  | 263d → 281d |  |  |
| 30 | Erstellung Qualitätsplan | 2021-03-08 → 2021-02-10 (-26d) | 2021-05-05 → 2021-03-08 (-58d) | 43d → 19d |  |  |
| 31 | Qualitätskonzept erarbeitet | 2021-05-06 → 2021-03-09 (-58d) | 2021-05-06 → 2021-03-09 (-58d) |  |  |  |
| 32 | Überprüfung der Dokumentation | 2021-05-03 → 2021-03-01 (-63d) | 2021-07-05 → 2021-07-01 (-4d) | 46d → 89d | none → 18 |  |
| 33 | Dokumente zur Nachnutzung stehen bereit | 2021-07-06 → 2021-07-02 (-4d) | 2021-07-06 → 2021-07-02 (-4d) |  |  |  |
| 34 | Überprüfung der Datanbank auf Anforderungen der GDI-DE und Projektpartner | 2021-06-04 → 2021-06-02 (-2d) | 2021-09-03 → 2021-09-01 (-2d) |  |  |  |
| 35 | Überprüfung der importierten Daten | 2021-06-07 → 2021-03-01 (-98d) | 2021-09-01 → 2021-06-08 (-85d) | 63d → 72d | none → 40 |  |
| 39 | AP2 (Datenimport) |  | 2021-06-03 → 2021-06-01 (-2d) | 189d → 187d |  |  |
| 40 | Erste Datensichtungen | 2021-06-03 → 2021-03-01 (-94d) | 2021-06-03 → 2021-03-01 (-94d) |  |  |  |
| 41 | Zentrale Datenbank mit allen benötigten Daten | 2021-06-04 → 2021-06-02 (-2d) | 2021-06-04 → 2021-06-02 (-2d) |  |  |  |

## Version 6 (saved 2024-07-03)

Last finish stays 2022-05-27.

Removed: 21 Fall: intelligentes/kommunenübergreifendes Verkehrsmanagment; 22 Fall: Harmonisierung von Gebäudedaten; 23 Fall: Prozessoptimierung der Erstellung von Lärmkarten; 24 Fall: ?

Changed:

| ID | Task | Start | Finish | Duration | Predecessors |
| --- | --- | --- | --- | --- | --- |
| 5 | Lizenzschließung mit DLZ zur Datennutzung |  | 2021-01-18 → 2021-01-25 (+7d) | 11d → 16d |  |
| 8 | Gespräche zu AP5 (Services und APIs) | 2021-01-11 → 2021-03-01 (+49d) | 2021-01-18 → 2021-03-05 (+46d) | 6d → 5d |  |
| 9 | Nicht Haupt-AP Aufgaben koordiniert | 2021-01-25 → 2021-03-08 (+42d) | 2021-01-25 → 2021-03-08 (+42d) |  |  |
| 13 | **AP7 (Anwendungsfall Klima und Mobilität)** |  | 2021-03-31 → 2021-04-02 (+2d) | 142d → 144d |  |
| 18 | Dokumentation des Anwendungsfalls (Klima&Mobilität + inhaltlich&funktional) |  | 2021-02-26 → 2021-04-02 (+35d) | 94d → 119d |  |
| 20 | Ausarbeitung der Anwendungsszenarien |  | 2021-01-12 → 2021-02-26 (+45d) | 30d → 63d |  |
| 21 | Erste ausgearbeitete Version von Anwendungsfällen der Projektpartner | 2021-01-13 → 2021-03-01 (+47d) | 2021-01-13 → 2021-03-01 (+47d) |  |  |
| 22 | Formulierung (SMARTer) Szenarien | 2021-01-12 → 2021-03-01 (+48d) | 2021-02-09 → 2021-03-29 (+48d) |  |  |
| 23 | UAP 7.3 (Datenbereitstellung und Visualisierung) | 2021-02-10 → 2021-03-01 (+19d) | 2021-03-31 → 2021-03-29 (-2d) | 36d → 21d | 24 → none |
| 24 | Konsolidierte Fassung der Anwendungsfälle | 2021-02-10 → 2021-04-02 (+51d) | 2021-02-10 → 2021-04-02 (+51d) |  | 22 → 22, 23 |
| 25 | **AP8 (Qualitätssicherung und Verwertung)** | 2021-02-10 → 2021-02-22 (+12d) |  | 281d → 273d |  |
| 26 | Erstellung Qualitätsplan | 2021-02-10 → 2021-02-22 (+12d) | 2021-03-08 → 2021-03-12 (+4d) | 19d → 15d |  |
| 27 | Qualitätskonzept erarbeitet | 2021-03-09 → 2021-03-15 (+6d) | 2021-03-09 → 2021-03-15 (+6d) |  |  |
| 28 | Überprüfung der Dokumentation |  |  |  | 18 → none |

## Version 7 (saved 2024-07-03)

Last finish stays 2022-05-27.

Added:

| ID | Task | Duration | Start | Finish | Resources |
| --- | --- | --- | --- | --- | --- |
| 20 | Fall: intelligentes/kommunenübergreifendes Verkehrsmanagment | 15d | 2020-12-15 | 2021-01-04 | Kreis Lippe (LIP) |
| 21 | Fall: Harmonisierung von Gebäudedaten | 12d | 2020-12-02 | 2020-12-17 | Vogelsbergkreis (VK) |
| 22 | Fall: Prozessoptimierung der Erstellung von Lärmkarten | 10d | 2020-12-10 | 2020-12-23 | Stadt Leipzig (L) |
| 23 | Fall: ? | 24d | 2020-12-02 | 2021-01-04 | Stadt Dresden (DD) |

Removed: 5 Lizenzschließung mit DLZ zur Datennutzung

Changed:

| ID | Task | Start | Finish | Duration | Predecessors | Other |
| --- | --- | --- | --- | --- | --- | --- |
| 7 | Gespräche zu AP5 (Services und APIs) | 2021-03-01 → 2020-12-10 (-81d) | 2021-03-05 → 2020-12-17 (-78d) | 5d → 6d |  |  |
| 8 | Nicht Haupt-AP Aufgaben koordiniert | 2021-03-08 → 2020-12-18 (-80d) | 2021-03-08 → 2020-12-18 (-80d) |  |  |  |
| 12 | **AP7 (Anwendungsfall Klima und Mobilität)** |  | 2021-04-02 → 2021-03-03 (-30d) | 144d → 122d |  |  |
| 17 | Dokumentation des Anwendungsfalls (Klima&Mobilität + inhaltlich&funktional) |  | 2021-04-02 → 2021-02-26 (-35d) | 119d → 94d |  |  |
| 19 | **Ausarbeitung der Anwendungsszenarien** |  | 2021-02-26 → 2021-01-04 (-53d) | 63d → 24d |  |  |
| 24 | Erste ausgearbeitete Version von Anwendungsfällen der Projektpartner | 2021-03-01 → 2021-01-05 (-55d) | 2021-03-01 → 2021-01-05 (-55d) |  |  |  |
| 25 | UAP 7.3 (Datenbereitstellung und Visualisierung) | 2021-03-01 → 2021-01-05 (-55d) | 2021-03-29 → 2021-03-03 (-26d) | 21d → 42d | none → 24 |  |
| 26 | Formulierung SMARTer Szenarien | 2021-03-01 → 2021-01-05 (-55d) | 2021-03-29 → 2021-02-02 (-55d) |  |  | was named Formulierung (SMARTer) Szenarien |
| 27 | Konsolidierte Fassung der Anwendungsfälle | 2021-04-02 → 2021-02-03 (-58d) | 2021-04-02 → 2021-02-03 (-58d) |  | 26, 25 → 26 |  |
| 28 | **AP8 (Qualitätssicherung und Verwertung)** | 2021-02-22 → 2021-02-03 (-19d) |  | 273d → 286d | none → 27 |  |
| 29 | Erstellung Qualitätsplan | 2021-02-22 → 2021-02-03 (-19d) | 2021-03-12 → 2021-03-01 (-11d) | 15d → 19d |  |  |
| 30 | Qualitätskonzept erarbeitet | 2021-03-15 → 2021-03-02 (-13d) | 2021-03-15 → 2021-03-02 (-13d) |  |  |  |
| 31 | Überprüfung der Dokumentation |  |  |  | none → 17 |  |

## Version 8 (saved 2024-07-03)

Last finish 2022-05-27 → 2022-11-30 (+187d).

Added:

| ID | Task | Duration | Start | Finish | Predecessors |
| --- | --- | --- | --- | --- | --- |
| 5 | Lizenzschließung mit DLZ zur Datennutzung | 16d | 2021-01-04 | 2021-01-25 |  |
| 13 | **Berichtspflichten** | 432d | 2021-04-05 | 2022-11-29 |  |
| 14 | Zwischenbericht I | 19d | 2021-04-05 | 2021-04-29 |  |
| 15 | Zwischenbericht I eingereicht | 0d | 2021-04-30 | 2021-04-30 | 14 |
| 16 | Zwischenbericht II | 19d | 2022-04-04 | 2022-04-28 |  |
| 17 | Zwischenbericht II eingereicht | 0d | 2022-04-29 | 2022-04-29 | 16 |
| 18 | Schlussbericht | 17d | 2022-11-07 | 2022-11-29 |  |
| 19 | Schlussbericht eingereicht | 0d | 2022-11-30 | 2022-11-30 | 18 |
| 32 | Konsolidierte Ausarbeitung der Anwendungsfälle | 0d | 2021-07-08 | 2021-07-08 | 31 |

Removed: 20 Fall: intelligentes/kommunenübergreifendes Verkehrsmanagment; 21 Fall: Harmonisierung von Gebäudedaten; 22 Fall: Prozessoptimierung der Erstellung von Lärmkarten; 23 Fall: ?

Changed:

| ID | Task | Start | Finish | Duration | Predecessors | Other |
| --- | --- | --- | --- | --- | --- | --- |
| 8 | Gespräche zu AP5 organisieren (Services und APIs) | 2020-12-10 → 2021-03-08 (+88d) | 2020-12-17 → 2021-03-15 (+88d) |  |  | was named Gespräche zu AP5 (Services und APIs) |
| 9 | Nicht Haupt-AP Aufgaben koordiniert | 2020-12-18 → 2021-03-16 (+88d) | 2020-12-18 → 2021-03-16 (+88d) |  |  |  |
| 20 | **AP7 (Anwendungsfall Klima und Mobilität)** |  | 2021-03-03 → 2022-05-30 (+453d) | 122d → 445d |  |  |
| 25 | Dokumentation des Anwendungsfalls (Klima&Mobilität + inhaltlich&funktional) |  | 2021-02-26 → 2022-05-30 (+458d) | 94d → 420d |  |  |
| 27 | Ausarbeitung der Anwendungsszenarien |  | 2021-01-04 → 2021-03-05 (+60d) | 24d → 68d |  |  |
| 28 | Erste ausgearbeitete Version von Anwendungsfällen der Projektpartner | 2021-01-05 → 2021-03-08 (+62d) | 2021-01-05 → 2021-03-08 (+62d) |  |  |  |
| 29 | Vorformulierung (SMARTer) Szenarien | 2021-01-05 → 2021-03-05 (+59d) | 2021-02-02 → 2021-06-03 (+121d) | 21d → 65d |  | was named Formulierung SMARTer Szenarien |
| 30 | UAP 7.3 (Datenbereitstellung und Visualisierung) | 2021-01-05 → 2021-03-05 (+59d) | 2021-03-03 → 2021-06-03 (+92d) | 42d → 65d | 28 → none |  |
| 31 | SMARTe Ausarbeitung der Anwendungsfälle | 2021-02-03 → 2021-06-04 (+121d) | 2021-02-03 → 2021-07-07 (+154d) | 0d → 24d | 29 → 29, 30 | was named Konsolidierte Fassung der Anwendungsfälle |
| 33 | **AP8 (Qualitätssicherung und Verwertung)** | 2021-02-03 → 2021-03-08 (+33d) |  | 286d → 263d | 31 → none |  |
| 34 | Erstellung Qualitätsplan | 2021-02-03 → 2021-03-08 (+33d) | 2021-03-01 → 2021-05-05 (+65d) | 19d → 43d |  |  |
| 35 | Qualitätskonzept erarbeitet | 2021-03-02 → 2021-05-06 (+65d) | 2021-03-02 → 2021-05-06 (+65d) |  |  |  |
| 36 | Überprüfung der Dokumentation | 2021-03-01 → 2021-05-03 (+63d) | 2021-07-01 → 2021-07-05 (+4d) | 89d → 46d | 25 → none |  |
| 37 | Dokumente zur Nachnutzung stehen bereit | 2021-07-02 → 2021-07-06 (+4d) | 2021-07-02 → 2021-07-06 (+4d) |  |  |  |
| 38 | Überprüfung der Datanbank auf Anforderungen der GDI-DE und Projektpartner | 2021-06-02 → 2021-06-28 (+26d) | 2021-09-01 → 2021-09-27 (+26d) |  |  |  |
| 39 | Überprüfung der importierten Daten | 2021-03-01 → 2021-06-07 (+98d) | 2021-06-08 → 2021-09-01 (+85d) | 72d → 63d | 44 → none |  |
| 43 | AP2 (Datenimport) |  | 2021-06-01 → 2021-06-03 (+2d) | 187d → 189d |  |  |
| 44 | Erste Datensichtungen | 2021-03-01 → 2021-06-03 (+94d) | 2021-03-01 → 2021-06-03 (+94d) |  |  |  |
| 45 | Zentrale Datenbank mit allen benötigten Daten | 2021-06-02 → 2021-06-28 (+26d) | 2021-06-02 → 2021-06-28 (+26d) |  |  |  |

## Version 9 (saved 2024-07-03)

Last finish stays 2022-11-30.

Changed:

| ID | Task | Start | Finish | Duration | Predecessors |
| --- | --- | --- | --- | --- | --- |
| 29 | Vorformulierung (SMARTer) Szenarien |  | 2021-06-03 → 2021-04-08 (-56d) | 65d → 25d |  |
| 30 | UAP 7.3 (Datenbereitstellung und Visualisierung) |  | 2021-06-03 → 2021-04-08 (-56d) | 65d → 25d |  |
| 31 | SMARTe Ausarbeitung der Anwendungsfälle | 2021-06-04 → 2021-04-09 (-56d) | 2021-07-07 → 2021-05-12 (-56d) |  |  |
| 32 | Konsolidierte Ausarbeitung der Anwendungsfälle | 2021-07-08 → 2021-05-13 (-56d) | 2021-07-08 → 2021-05-13 (-56d) |  |  |
| 34 | Erstellung Qualitätsplan |  | 2021-05-05 → 2021-03-26 (-40d) | 43d → 15d |  |
| 35 | Qualitätskonzept erarbeitet | 2021-05-06 → 2021-03-29 (-38d) | 2021-05-06 → 2021-03-29 (-38d) |  |  |
| 36 | Überprüfung der Dokumentation | 2021-05-03 → 2021-03-29 (-35d) |  | 46d → 71d |  |
| 38 | Überprüfung der Datanbank auf Anforderungen der GDI-DE und Projektpartner | 2021-06-28 → 2021-06-02 (-26d) | 2021-09-27 → 2021-09-01 (-26d) |  |  |
| 39 | Überprüfung der importierten Daten | 2021-06-07 → 2021-03-29 (-70d) | 2021-09-01 → 2021-07-05 (-58d) | 63d → 71d | none → 44 |
| 43 | AP2 (Datenimport) |  | 2021-06-03 → 2021-06-01 (-2d) | 189d → 187d |  |
| 44 | Erste Datensichtungen | 2021-06-03 → 2021-03-04 (-91d) | 2021-06-03 → 2021-03-04 (-91d) |  |  |
| 45 | Zentrale Datenbank mit allen benötigten Daten | 2021-06-28 → 2021-06-02 (-26d) | 2021-06-28 → 2021-06-02 (-26d) |  |  |

## Version 10 (saved 2024-07-03)

Last finish stays 2022-11-30.

Removed: 32 Konsolidierte Ausarbeitung der Anwendungsfälle

Changed:

| ID | Task | Start | Finish | Duration | Other |
| --- | --- | --- | --- | --- | --- |
| 20 | **AP7 (Anwendungsfall Klima und Mobilität)** |  | 2022-05-30 → 2021-04-06 (-419d) | 445d → 146d |  |
| 25 | Dokumentation des Anwendungsfalls (Klima&Mobilität + inhaltlich&funktional) |  | 2022-05-30 → 2021-04-02 (-423d) | 420d → 119d |  |
| 29 | Formulierung (SMARTer) Szenarien | 2021-03-05 → 2021-03-08 (+3d) | 2021-04-08 → 2021-04-06 (-2d) | 25d → 22d | was named Vorformulierung (SMARTer) Szenarien |
| 30 | UAP 7.3 (Datenbereitstellung und Visualisierung) | 2021-03-05 → 2021-03-08 (+3d) | 2021-04-08 → 2021-04-06 (-2d) | 25d → 22d |  |
| 31 | Konsolidierte Fassung der Anwendungsfälle | 2021-04-09 → 2021-04-07 (-2d) | 2021-05-12 → 2021-04-07 (-35d) | 24d → 0d | was named SMARTe Ausarbeitung der Anwendungsfälle |

## Version 11 (saved 2024-07-03)

Last finish 2022-11-30 → 2022-05-27 (-187d).

Removed: 13 Berichtspflichten; 14 Zwischenbericht I; 15 Zwischenbericht I eingereicht; 16 Zwischenbericht II; 17 Zwischenbericht II eingereicht; 18 Schlussbericht; 19 Schlussbericht eingereicht

Changed:

| ID | Task | Start | Finish | Duration | Other |
| --- | --- | --- | --- | --- | --- |
| 8 | Gespräche zu AP5 (Services und APIs) | 2021-03-08 → 2021-03-01 (-7d) | 2021-03-15 → 2021-03-05 (-10d) | 6d → 5d | was named Gespräche zu AP5 organisieren (Services und APIs) |
| 9 | Nicht Haupt-AP Aufgaben koordiniert | 2021-03-16 → 2021-03-08 (-8d) | 2021-03-16 → 2021-03-08 (-8d) |  |  |
| 13 | **AP7 (Anwendungsfall Klima und Mobilität)** |  | 2021-04-06 → 2021-04-02 (-4d) | 146d → 144d |  |
| 22 | Formulierung (SMARTer) Szenarien |  | 2021-04-06 → 2021-03-29 (-8d) | 22d → 16d |  |
| 23 | UAP 7.3 (Datenbereitstellung und Visualisierung) |  | 2021-04-06 → 2021-03-29 (-8d) | 22d → 16d |  |
| 24 | Konsolidierte Fassung der Anwendungsfälle | 2021-04-07 → 2021-04-02 (-5d) | 2021-04-07 → 2021-04-02 (-5d) |  |  |
| 25 | **AP8 (Qualitätssicherung und Verwertung)** | 2021-03-08 → 2021-02-22 (-14d) |  | 263d → 273d |  |
| 26 | Erstellung Qualitätsplan | 2021-03-08 → 2021-02-22 (-14d) | 2021-03-26 → 2021-03-19 (-7d) | 15d → 20d |  |
| 27 | Qualitätskonzept erarbeitet | 2021-03-29 → 2021-03-22 (-7d) | 2021-03-29 → 2021-03-22 (-7d) |  |  |
| 28 | Überprüfung der Dokumentation | 2021-03-29 → 2021-03-01 (-28d) | 2021-07-05 → 2021-07-01 (-4d) | 71d → 89d |  |
| 29 | Dokumente zur Nachnutzung stehen bereit | 2021-07-06 → 2021-07-02 (-4d) | 2021-07-06 → 2021-07-02 (-4d) |  |  |
| 31 | Überprüfung der importierten Daten | 2021-03-29 → 2021-03-01 (-28d) | 2021-07-05 → 2021-06-08 (-27d) | 71d → 72d |  |
| 36 | Erste Datensichtungen | 2021-03-04 → 2021-03-01 (-3d) | 2021-03-04 → 2021-03-01 (-3d) |  |  |
