# Projektplan mFund envVisio-GI

How a schedule from GanttProject changed from version to version. A marks actual dates.

## Version 1 (saved 2024-07-03)

| ID | WBS | Task | Duration | Start | Finish | Predecessors |
| --- | --- | --- | --- | --- | --- | --- |
| 1 | 1 | **Projektkoordination** | 279d | 2020-09-15 | 2021-10-08 |  |
| 2 |  | Regelmäßige Treffen der AG Anwendungsfall organisieren | 26d | 2020-09-15 | 2020-10-20 |  |
| 3 |  | AG Anwendungsfall Treffen Termin | 0d | 2020-10-21 | 2020-10-21 | 2 |
| 4 |  | Gesamtprojekttreffen Terminfindung | 21d | 2020-12-01 | 2020-12-29 |  |
| 5 |  | Lizenzschließung mit DLZ zur Datennutzung | 16d | 2021-01-04 | 2021-01-25 |  |
| 6 |  | Konsortialmeeting mit Projektträger | 0d | 2021-10-01 | 2021-10-01 |  |
| 7 | 1.6 | **Unterarbeitspaketkoordination** | 223d | 2020-12-02 | 2021-10-08 |  |
| 8 |  | Gespräche zu AP2 (Datenimport) | 6d | 2020-12-02 | 2020-12-09 |  |
| 9 |  | Gespräche zu AP5 organisieren (Services und APIs) | 6d | 2021-03-08 | 2021-03-15 |  |
| 10 |  | Nicht Haupt-AP Aufgaben koordiniert | 0d | 2021-03-16 | 2021-03-16 | 8, 9 |
| 11 |  | Gespräch zu 7.1 (Konzeption und Spezifikation) | 6d | 2020-12-18 | 2020-12-25 |  |
| 12 |  | Gespräch zu 7.4 (Spezifikation des Datenmanagments) | 7d | 2020-12-25 | 2021-01-04 |  |
| 13 |  | Gespräch zu 7.5 (Implementierung von Anwendungsszenarien) | 5d | 2021-10-04 | 2021-10-08 |  |
| 14 | 2 | **Berichtspflichten** | 432d | 2021-04-05 | 2022-11-29 |  |
| 15 |  | Zwischenbericht I | 19d | 2021-04-05 | 2021-04-29 |  |
| 16 |  | Zwischenbericht I eingereicht | 0d | 2021-04-30 | 2021-04-30 | 15 |
| 17 |  | Zwischenbericht II | 19d | 2022-04-04 | 2022-04-28 |  |
| 18 |  | Zwischenbericht II eingereicht | 0d | 2022-04-29 | 2022-04-29 | 17 |
| 19 |  | Schlussbericht | 17d | 2022-11-07 | 2022-11-29 |  |
| 20 |  | Schlussbericht eingereicht | 0d | 2022-11-30 | 2022-11-30 | 19 |
| 21 | 3 | **AP7 (Anwendungsfall Klima und Mobilität)** | 445d | 2020-09-15 | 2022-05-30 |  |
| 22 |  | Präsentation über GDI Dokumente & Anforderungen | 1d | 2020-09-21 | 2020-09-21 |  |
| 23 |  | Relevante GDI Dokumente den Projektpartnern bekannt | 0d | 2020-09-22 | 2020-09-22 | 22 |
| 24 |  | Erste Eruierungen der Anforderungen Anwendungsfall Klima&Mobilität | 26d | 2020-09-15 | 2020-10-20 |  |
| 25 |  | Bereich im GDI-DE Wiki zur Kommunikation und Organisation erstellt | 0d | 2020-10-20 | 2020-10-20 |  |
| 26 |  | Dokumentation des Anwendungsfalls (Klima&Mobilität + inhaltlich&funktional) | 420d | 2020-10-20 | 2022-05-30 | 25 |
| 27 |  | Schärfung der Anforderungen | 29d | 2020-10-22 | 2020-12-01 | 24FS+1d |
| 28 |  | Ausarbeitung der Anwendungsszenarien | 68d | 2020-12-02 | 2021-03-05 | 27 |
| 29 |  | Erste ausgearbeitete Version von Anwendungsfällen der Projektpartner | 0d | 2021-03-08 | 2021-03-08 | 28 |
| 30 |  | UAP 7.3 (Datenbereitstellung und Visualisierung) | 129d | 2021-03-05 | 2021-09-01 |  |
| 31 |  | Vorformulierung (SMARTer) Szenarien | 21d | 2021-09-02 | 2021-09-30 |  |
| 32 |  | SMARTe Ausarbeitung der Anwendungsfälle | 21d | 2021-10-01 | 2021-10-29 | 30, 31 |
| 33 |  | Konsolidierte Ausarbeitung der Anwendungsfälle | 0d | 2021-11-01 | 2021-11-01 | 32 |
| 34 | 4 | **AP8 (Qualitätssicherung und Verwertung)** | 300d | 2021-03-08 | 2022-04-29 |  |
| 35 |  | Erstellung Qualitätsplan | 149d | 2021-03-08 | 2021-09-30 |  |
| 36 |  | Qualitätskonzept erarbeitet | 0d | 2021-10-01 | 2021-10-01 | 35 |
| 37 |  | Überprüfung der Dokumentation | 176d | 2021-05-03 | 2022-01-03 |  |
| 38 |  | Dokumente zur Nachnutzung stehen bereit | 0d | 2022-01-04 | 2022-01-04 | 37 |
| 39 |  | Überprüfung der Datanbank auf Anforderungen der GDI-DE und Projektpartner | 67d | 2021-11-01 | 2022-02-01 | 44, 47 |
| 40 |  | Überprüfung der importierten Daten | 89d | 2021-09-01 | 2022-01-03 |  |
| 41 |  | Überprüfung der Anwendung | 87d | 2021-11-01 | 2022-03-01 | 48SS |
| 42 |  | Vergleich der finalen Anwendung mit SMART-Zielen | 43d | 2022-03-02 | 2022-04-29 | 49 |
| 43 | 5 | **Technische Vorgänge** | 382d | 2020-09-14 | 2022-03-01 |  |
| 44 |  | AP2 (Datenimport) | 295d | 2020-09-14 | 2021-10-29 |  |
| 45 |  | Dateneinsicht Kreis Lippe | 0d | 2021-08-05 | 2021-08-05 |  |
| 46 |  | Erste Datensichtungen | 0d | 2021-06-03 | 2021-06-03 |  |
| 47 |  | Zentrale Datenbank mit allen benötigten Daten | 0d | 2021-11-01 | 2021-11-01 | 44 |
| 48 |  | UAP 7.5 (Implementierung von Anwendungsszenarien) | 66d | 2021-11-01 | 2022-01-31 | 13 |
| 49 |  | Anwendungen sind Betriebsbereit | 0d | 2022-03-02 | 2022-03-02 | 41, 48 |
| 50 | 6 | **Hackathon** | 200d | 2021-08-23 | 2022-05-27 |  |
| 51 |  | Organisation Hackathon | 198d | 2021-08-23 | 2022-05-25 |  |
| 52 |  | Hackathon Durchführung | 2d | 2022-05-26 | 2022-05-27 | 51 |

## Version 2 (saved 2024-07-03)

Last finish stays 2022-11-30.

Added:

| ID | Task | Duration | Start | Finish |
| --- | --- | --- | --- | --- |
| 53 | Beschreibung Challenges für Hackathon | 41d | 2021-12-01 | 2022-01-26 |

Changed:

| ID | Task | Start | Finish | Duration | Predecessors | Other |
| --- | --- | --- | --- | --- | --- | --- |
| 30 | UAP 7.3 (Datenbereitstellung und Visualisierung) |  | 2021-09-01 → 2022-03-31 (+211d) | 129d → 280d |  |  |
| 31 | Anforderungen Qualitativ Messbar Formuliert | 2021-09-02 → 2021-12-16 (+105d) | 2021-09-30 → 2022-02-28 (+151d) | 21d → 53d |  | was named Vorformulierung (SMARTer) Szenarien |
| 32 | (SMARTe) Finale Ausarbeitung der Anwendungsfälle | 2021-10-01 → 2022-04-01 (+182d) | 2021-10-29 → 2022-04-29 (+182d) |  |  | was named SMARTe Ausarbeitung der Anwendungsfälle |
| 33 | Konsolidierte Ausarbeitung der Anwendungsfälle | 2021-11-01 → 2022-05-02 (+182d) | 2021-11-01 → 2022-05-02 (+182d) |  |  |  |
| 34 | **AP8 (Qualitätssicherung und Verwertung)** |  | 2022-04-29 → 2022-05-31 (+32d) | 300d → 322d |  |  |
| 37 | Überprüfung der Dokumentation |  | 2022-01-03 → 2022-05-31 (+148d) | 176d → 282d |  |  |
| 38 | Dokumente zur Nachnutzung stehen bereit | 2022-01-04 → 2022-06-01 (+148d) | 2022-01-04 → 2022-06-01 (+148d) |  |  |  |
| 39 | Überprüfung der Datanbank auf Anforderungen der GDI-DE und Projektpartner | 2021-11-01 → 2021-08-02 (-91d) | 2022-02-01 → 2022-04-29 (+87d) | 67d → 195d | 44, 47 → none |  |
| 40 | Überprüfung der importierten Daten |  | 2022-01-03 → 2022-03-31 (+87d) | 89d → 152d |  |  |
| 41 | Überprüfung der Anwendung | 2021-11-01 → 2022-02-01 (+92d) | 2022-03-01 → 2022-04-29 (+59d) | 87d → 64d |  |  |
| 42 | Vergleich der finalen Anwendung mit Zielen | 2022-03-02 → 2022-05-02 (+61d) | 2022-04-29 → 2022-05-31 (+32d) | 43d → 22d | 49 → none | was named Vergleich der finalen Anwendung mit SMART-Zielen |
| 43 | **Technische Vorgänge** |  | 2022-03-01 → 2022-04-29 (+59d) | 382d → 425d |  |  |
| 44 | AP2 (Datenimport) |  | 2021-10-29 → 2022-02-28 (+122d) | 295d → 381d |  |  |
| 47 | Zentrale Datenbank mit allen benötigten Daten | 2021-11-01 → 2022-03-01 (+120d) | 2021-11-01 → 2022-03-01 (+120d) |  |  |  |
| 48 | UAP 7.5 (Implementierung von Anwendungsszenarien) |  | 2022-01-31 → 2022-04-29 (+88d) | 66d → 130d |  |  |
| 49 | Anwendungen sind Betriebsbereit | 2022-03-02 → 2022-05-02 (+61d) | 2022-03-02 → 2022-05-02 (+61d) |  |  |  |

## Version 3 (saved 2024-07-03)

Last finish stays 2022-11-30.

Added:

| ID | Task | Duration | Start | Finish | Predecessors |
| --- | --- | --- | --- | --- | --- |
| 32 | Anfertigung Anforderungsmatrix | 21d | 2022-04-01 | 2022-04-29 |  |
| 43 | Auswertung Anforderungsmatrix | 6d | 2022-05-16 | 2022-05-23 | 32 |

Removed: 32 (SMARTe) Finale Ausarbeitung der Anwendungsfälle

Changed:

| ID | Task | Start | Finish | Duration | Predecessors |
| --- | --- | --- | --- | --- | --- |
| 33 | Konsolidierte Ausarbeitung der Anwendungsfälle |  |  |  | (SMARTe) Finale Ausarbeitung der Anwendungsfälle → 32 |
| 40 | Überprüfung der importierten Daten |  | 2022-03-31 → 2022-05-11 (+41d) | 152d → 181d |  |
| 41 | Überprüfung der Anwendung |  | 2022-04-29 → 2022-05-16 (+17d) | 64d → 75d |  |
| 44 | **Technische Vorgänge** |  | 2022-04-29 → 2022-05-16 (+17d) | 425d → 436d |  |
| 50 | Anwendungen sind Betriebsbereit | 2022-05-02 → 2022-05-17 (+15d) | 2022-05-02 → 2022-05-17 (+15d) |  |  |
